# Project Management for Preventing Cyber Aggression in the Maritime Domain

Schedule from MS Project, 2021-10-26 to 2022-10-03, A marks actual dates.
ASG Software Solutions

## Calendars

- Standard: Mon-Fri 08:00-12:00, 13:00-17:00; Sat-Sun off.

## Resources

| Resource | Group |
| --- | --- |
| Alan Runyan-Beebe | SNL |
| Jesus Carrete-Lopez | SNL |
| Paolo Macias | SNL |
| Arthur Eyzaguirre | SNL |
| Michael Bachman | SNL |
| Shannon Abbott | SNL |
| Jesse Thomas | SNL |

## Schedule

| ID | WBS | Task | Type | Duration | Start | Finish | Predecessors | Complete | Remaining | Total slack | Free slack | Constraint | Resources | Work | Actual work | Text7 |
| --- | --- | --- | --- | --- | --- | --- | --- | --- | --- | --- | --- | --- | --- | --- | --- | --- |
| 1 | 1 | **Strategy-Setting Phase** |  | 112.9d | 2021-10-26 A | 2022-03-31 |  | 32% | 77.17d | 132.1d |  |  |  | 678.98h | 489.6h |  |
| 2 | 1.1 | **Open Source research and analyze international Maritime Cybersecurity** |  | 39d | 2021-10-26 A | 2021-12-17 |  | 55% | 17.42d | 206d |  |  |  | 338.1h | 316h |  |
| 3 | 1.1.1 | Identified current issues related to DPRK cyber activity in the maritime industry |  | 1d | 2021-10-26 A | 2021-10-26 A |  | 100% |  |  |  |  | Alan Runyan-Beebe [5%]; Jesus Carrete-Lopez [5%]; Paolo Macias [5%] | 24h | 24h |  |
| 4 | 1.1.2 | Case studies identified |  | 5d | 2021-10-26 A | 2021-12-17 A |  | 100% |  |  |  | finish no earlier than 2021-12-17 | Alan Runyan-Beebe [20%]; Jesus Carrete-Lopez [20%] | 80h | 80h | Strategies and Plans |
| 5 | 1.1.3 | **Analysis on APTs and involvement in maritime industry** |  | 39d | 2021-10-26 A | 2021-12-17 |  | 48% | 20.25d | 206d |  |  |  | 234.1h | 212h | Goals and Objectives, List of Constraints |
| 6 | 1.1.3.1 | Maritime Targets |  | 7d | 2021-10-26 A | 2021-11-03 |  | 64% | 2.5d | 238d |  |  | Jesus Carrete-Lopez [10%]; Paolo Macias [10%] | 40h | 36h |  |
| 7 | 1.1.3.2 | TTPs specifically used in cyber operations within the maritime industry |  | 14d | 2021-10-26 A | 2021-11-12 |  | 32% | 9.5d | 0d |  |  | Jesus Carrete-Lopez [20%]; Paolo Macias [5%] | 79.8h | 72h |  |
| 8 | 1.1.3.3 | Identify at-risk regions and targets in maritime supply chain |  | 10d | 2021-12-06 A | 2021-12-17 | 7 | 43% | 5.75d | 206d |  |  | Jesus Carrete-Lopez [10%]; Paolo Macias [5%]; Alan Runyan-Beebe [5%] | 74.3h | 68h |  |
| 9 | 1.1.3.4 | Identify maritime industry stakeholders and partners and avenues of investment |  | 5.93d | 2021-10-26 A | 2021-11-16 | 7 | 76% | 1.43d | 229.57d |  |  | Jesus Carrete-Lopez [35%] | 40h | 36h |  |
| 10 | 1.2 | **Baltic and International Maritime Council (BIMCO) cybersecurity requirements and documentation** |  | 10d | 2021-10-26 A | 2021-11-08 A |  | 100% |  |  |  |  |  | 80h | 80h |  |
| 11 | 1.2.1 | Strategic cybersecurity assessment aligning with IMO and BIMCO requirements and national maritime and cyber legislation for partner nations |  | 10d | 2021-10-26 A | 2021-11-08 A |  | 100% |  |  |  |  | Alan Runyan-Beebe [10%]; Paolo Macias [10%] | 80h | 80h |  |
| 12 | 1.3 | **Map industry requirements with international cybersecurity frameworks to aid in implementation of technical measures.** |  | 102.9d | 2021-11-09 A | 2022-03-31 | 10 | 28% | 74.32d | 132.1d | 0d |  |  | 260.88h | 93.6h |  |
| 13 | 1.3.1 | NIST 800-53r5 |  | 3d | 2021-11-09 A | 2021-11-11 |  | 90% | 0.3d | 232d |  | finish no earlier than 2021-11-10 | Alan Runyan-Beebe; Paolo Macias [5%] | 15.44h | 15.2h |  |
| 14 | 1.3.2 | Analysis on the International Maritime Organization (Resolution MSC. 428(98)) |  | 1d | 2021-11-09 A | 2021-11-09 A | 13 | 100% |  |  |  |  | Alan Runyan-Beebe | 8h | 8h |  |
| 15 | 1.3.3 | ISO 27001 |  | 5d | 2021-11-09 A | 2021-11-15 A | 13 | 100% |  |  |  |  |  |  |  |  |
| 16 | 1.3.4 | Creating a common language for operators and owners to address cybersecurity risk, gaps, and vulnerabilities and providing controls and implementation measures to defend the maritime domain against cyber aggression |  | 5d | 2021-11-16 A | 2021-12-17 A | 15 | 100% |  |  |  | finish no earlier than 2021-12-17 | Alan Runyan-Beebe [10%] | 40h | 40h |  |
| 17 | 1.3.5 | Perform gap analysis |  | 5d | 2022-01-26 A | 2022-02-01 | 16 | 20% | 4d | 0.7d | 0d | finish no earlier than 2022-02-01 | Alan Runyan-Beebe | 24h | 8h |  |
| 18 | 1.3.6 | Create a Baseline |  | 14d | 2022-02-02 A | 2022-02-21 | 17 | 5% | 13.3d | 0d |  |  | Alan Runyan-Beebe | 112h | 5.6h |  |
| 19 | 1.3.7 | Adapting Emerging technologies |  | 30d | 2022-01-04 A | 2022-03-31 | 18 | 7% | 27.9d | 132.1d |  |  | Jesus Carrete-Lopez [20%]; Paolo Macias [20%] | 61.44h | 16.8h |  |
| 20 | 1.4 | In coordination with the Cyprus’ International Maritime Ecosystem for Cybersecurity (IMEC), conduct in-depth research and analysis on APTs that target the maritime industry |  | 46d | 2021-12-20 | 2022-02-21 | 16 |  |  | 160d |  |  |  |  |  |  |
| 21 | 2 | Strategy Developed and drafted for release | milestone | 0d | 2022-03-31 | 2022-03-31 | 12 |  |  | 132.1d |  |  |  |  |  |  |
| 22 | 3 | **Curriculum Development (Revised and updated)** |  | 47d | 2021-11-29 A | 2022-02-01 |  | 23% | 36.26d | 174d |  |  |  | 500.8h | 120.16h |  |
| 23 | 3.1 | Introduction to DPRK illicit cyber-enabled maritime activity |  | 2d | 2021-11-29 A | 2021-11-30 |  | 15% | 1.7d | 219d |  |  | Alan Runyan-Beebe [10%]; Paolo Macias [10%]; Jesus Carrete-Lopez [15%]; Arthur Eyzaguirre [5%] | 3.2h | 0.96h |  |
| 24 | 3.2 | Cybersecurity Framework |  | 8d | 2021-12-13 A | 2021-12-22 |  | 90% | 0.8d | 203d |  | start no earlier than 2021-12-13 | Alan Runyan-Beebe [25%]; Arthur Eyzaguirre [25%]; Jesus Carrete-Lopez [25%]; Paolo Macias [25%] | 64h | 57.6h |  |
| 25 | 3.3 | Risk Assessment with included exercise |  | 1d | 2022-01-04 A | 2022-01-04 |  | 90% | 0.1d | 192d | 0d |  | Alan Runyan-Beebe | 8h | 7.2h |  |
| 26 | 3.4 | Threat Hunting |  | 1d | 2022-01-05 | 2022-01-05 | 25 |  |  | 192d | 0d |  | Paolo Macias | 8h |  |  |

Notes:
- 1: Text1: VPEND<VP ID="0_134424" TYP="0" />
- 2: Text1: VPEND<VP ID="0_168547" TYP="0" />
- 4: Text1: VPDATA:<VP ID="0_17185" TYP="0"><VP ID="0_108287" TYP="3" /><VP ID="0_17253" TYP="2" /><VP ID="0_20340" TYP="2"><VP ID="0_79735" TYP="3" /><VP ID="0_79733" TYP="3" /><VP ID="0_79736" TYP="3" /><VP ID="0_79731" TYP="3" /><VP ID="0_22284" TYP="3" /></VP><VP / Text2: VPEND ID="0_13058" TYP="2"><VP ID="0_87966" TYP="3" /></VP><VP ID="0_17301" TYP="1" /></VP>
- 5: Text1: VPDATA:<VP ID="0_80816" TYP="0"><VP ID="0_97923" TYP="3" /><VP ID="0_80996" TYP="2"><VP ID="0_141944" TYP="3" /><VP ID="0_92093" TYP="3" /><VP ID="0_81772" TYP="3" /></VP><VP ID="0_113117" TYP="2"><VP ID="0_141946" TYP="3" /></VP><VP ID="0_17301" TYP="1" / Text2: VPEND/></VP>
- 17: Identify gaps in governance to build cybersecurity controls and technological enhancements / Identify implementation measures to mitigate risks posed by gaps found in analysis / Need to identify gaps from discussions from IMEC strategy phase
- 18: * .; ; .; ; a.Create baseline maritime cybersecurity assessment with methodologies for CSIRT development with partner countries public/private sector / a.Map assessment to cybersecurity controls and known APT cyber risks / b.Configure assessments to vessel specific and port specific requirements
- 19: * .; ; .; ; a. Conduct research and analysis to determine implications of adapting emerging technologies such as AI, ML, big data, and blockchain/ledgers to enhance maritime operations and security / a. Determine the current state of emerging technologies in the maritime industry and other industries for potential adaptation to maritime objectives / b.Establish indicators indicative of potential alternative futures where operators utilize these technologies in the maritime industry to determine the future threat landscape of these technologies / c.Using this research and analysis determine the likely future state of emerging technology adoption in the maritime industry
- 24: SAND2021-0673

| ID | WBS | Task | Type | Duration | Start | Finish | Predecessors | Complete | Remaining | Total slack | Free slack | Constraint | Resources | Work | Actual work | Text1 |
| --- | --- | --- | --- | --- | --- | --- | --- | --- | --- | --- | --- | --- | --- | --- | --- | --- |
| 27 | 3.5 | **Table-top Exercise: Developing CSF capabilities** |  | 14d | 2022-01-04 A | 2022-01-21 |  | 25% | 10.5d | 181d |  |  | Alan Runyan-Beebe; Paolo Macias | 240h | 54.4h |  |
| 28 | 3.5.1 | CSF Prioritizing & Ranking System |  | 5d | 2022-01-10 A | 2022-01-14 |  | 80% | 1d | 1d | 0d |  | Alan Runyan-Beebe | 40h | 32h |  |
| 29 | 3.5.2 | TTX CSF Case Studies |  | 5d | 2022-01-14 A | 2022-01-20 | 28 | 40% | 3d | 182d |  |  | Paolo Macias | 40h | 16h |  |
| 30 | 3.5.3 | **Information System Assessment exercise** |  | 14d | 2022-01-04 | 2022-01-21 |  |  |  |  |  |  |  |  |  |  |
| 31 | 3.5.3.1 | Reference TTP identified |  | 14d | 2022-01-04 | 2022-01-21 |  |  |  | 181d | 0d |  |  |  |  |  |
| 32 | 3.5.4 | Case study completed and dry runs | milestone | 0d | 2022-01-21 | 2022-01-21 | 31 |  |  | 181d |  |  |  |  |  |  |
| 33 | 3.6 | **Cyber Threat** |  | 1d | 2022-01-06 | 2022-01-06 |  |  |  | 192d |  |  | Jesus Carrete-Lopez [20%]; Paolo Macias [20%] |  |  |  |
| 34 | 3.6.1 | Threat Types and APT |  | 1d | 2022-01-06 | 2022-01-06 | 26 |  |  | 192d |  |  |  |  |  |  |
| 35 | 3.7 | **Incident Response Recover Plans (Revised and updated)** |  | 37d | 2021-12-13 | 2022-02-01 |  |  |  | 174d |  |  | Alan Runyan-Beebe [20%]; Jesus Carrete-Lopez [20%]; Paolo Macias [20%] | 177.6h |  |  |
| 36 | 3.7.1 | Incident Response Lifecycle |  | 1d | 2021-12-13 | 2021-12-13 |  |  |  | 185d | 0d | start no earlier than 2021-12-13 |  |  |  |  |
| 37 | 3.7.2 | Pre-Incident Actions |  | 2d | 2021-12-14 | 2021-12-15 | 36 |  |  | 185d | 0d | start no earlier than 2021-12-13 |  |  |  |  |
| 38 | 3.7.3 | Cybersecurity Incident Response Team and Security Operation Center |  | 2d | 2021-12-16 | 2021-12-17 | 37 |  |  | 185d | 11d | start no earlier than 2021-12-13 |  |  |  |  |
| 39 | 3.7.4 | Incident Response |  | 2d | 2022-01-04 | 2022-01-05 | 38 |  |  | 174d | 0d | start no earlier than 2022-01-04 |  |  |  |  |
| 40 | 3.7.5 | Post Incident response (Recovery) |  | 2d | 2022-01-06 | 2022-01-07 | 39 |  |  | 174d | 0d | start no earlier than 2022-01-04 |  |  |  |  |
| 41 | 3.7.6 | Incident Scenarios Table-Top and Case Studies |  | 2d | 2022-01-10 | 2022-01-11 | 40 |  |  | 174d | 0d |  |  |  |  |  |
| 42 | 3.7.7 | Translation of Material |  | 14d | 2022-01-12 | 2022-01-31 | 41 |  |  | 174d | 0d |  |  |  |  |  |
| 43 | 3.7.8 | Review and dry run on material |  | 1d | 2022-02-01 | 2022-02-01 | 42 |  |  | 174d | 0d |  |  |  |  |  |
| 44 | 4 | All Curriculum developed and released | milestone | 0d | 2022-02-01 | 2022-02-01 | 43 |  |  | 174d |  |  |  |  |  |  |
| 45 | 5 | **IMEC Strategy-setting Phase** |  | 27d | 2022-02-14 | 2022-03-22 |  |  |  | 139d |  |  |  |  |  | VPEND<VP ID="0_134450" TYP="0" /> |
| 46 | 5.1 | SNL travels to Cyprus to review Strategy and Curriculum |  | 8d | 2022-02-14 | 2022-02-23 |  |  |  | 158d |  | start no earlier than 2022-02-14 |  |  |  |  |
| 47 | 5.2 | Consult with IMEC and draft communique - Outline on roles and responsibilities |  | 21d | 2022-02-22 | 2022-03-22 |  |  |  | 139d | 0d | start no earlier than 2022-02-22 |  |  |  |  |
| 48 | 5.3 | IMEC publishes communique | milestone | 0d | 2022-03-22 | 2022-03-22 | 47 |  |  | 139d |  |  |  |  |  |  |
| 49 | 6 | **Engagement Phase** |  | 127d | 2022-03-07 | 2022-08-30 |  |  |  |  |  |  |  |  |  | VPEND<VP ID="0_134633" TYP="0" /> |
| 50 | 6.1 | **Workshop One** |  | 17d | 2022-04-11 | 2022-05-03 |  |  |  | 109d |  |  |  |  |  |  |
| 51 | 6.1.1 | Day 1 |  | 1d | 2022-04-11 | 2022-04-11 |  |  |  | 109d | 0d | start no earlier than 2022-04-11 |  |  |  |  |
| 52 | 6.1.2 | Day 2 |  | 1d | 2022-04-12 | 2022-04-12 | 51 |  |  | 109d | 0d |  |  |  |  |  |
| 53 | 6.1.3 | Day 3 |  | 1d | 2022-04-13 | 2022-04-13 | 52 |  |  | 109d | 0d |  |  |  |  |  |
| 54 | 6.1.4 | Event Report |  | 14d | 2022-04-14 | 2022-05-03 | 53 |  |  | 109d | 0d |  |  |  |  |  |
| 55 | 6.1.5 | Workshop Complete and Event Report Submited | milestone | 0d | 2022-05-03 | 2022-05-03 | 54 |  |  | 109d |  |  |  |  |  |  |

Notes:
- 28: Information System Assessment Exercise / Prioritize and linking. / ·Assessment through fictional environment / ·Make decision on throughput / ·Discussions on gap analysis / ·Objective: Assessment review
- 29: Participants examine previously discussed or new case studies involving cyber incidents. Break into groups to develop post-mortem goals and priorities that could have prevented or mitigated the incident based on the five functions, categories, and subcategories. Identify cybersecurity gaps and items executed well in the case studies.
- 33: Threat Intelligence Overview / Types of Cyber Threat Intelligence / CISA Open-source intelligence / MITRE Attack / Malware Sandbox
- 37: Cyber At Risk Score / Gap Analysis Against Target Maturity Level / Strategic Roadmap / Implementation Tiers / ·Partial / ·Risk Informed / ·Repeatable / ·Adaptive / Capability Maturity Model Integration / ·Initial ==> Managed ==> Defined ==> Quantitatively Managed ==> Optimizing
- 51: 09:00-09:30Welcome and Introduction 09:30-10:30Session 1: Discussion on APT threat landscape and intersection of cyber domain and marine global transportation industry 10:30-10:45Break 10:45-11:45Session 2: Case study emphasizing severity, impact, and cybersecurity gaps facing the maritime industry 11:45-13:00Lunch 13:00-14:00Session 3: Foundational cybersecurity best practices and background development to ensure understanding at all levels 14:00-14:15Break 14:15-15:30Session 4: Utilizing cybersecurity controls and frameworks in the maritime industry 15:30-16:00End-of-Day Remarks and Adjourn
- 52: 09:00-09:30Welcome and Day 1 Review 09:30-10:30Session 1: Vessel and port-specific cybersecurity risk and mitigation strategies 10:30-10:45Break 10:45-11:45Session 2: Breakdown of IMO, BIMCO, and other international standards 11:45-13:00Lunch 13:00-14:00Session 3: National and regional cybersecurity and maritime security requirements and how they can protect against cyber aggression 14:00-14:15Break 14:15-15:30Session 4: Overview of maritime cyber assessment for partners, how to conduct, apply mitigations, and reassess for continual improvement 15:30-16:00End-of-Day Remarks and Adjourn
- 53: 09:00-09:30Welcome and Day 2 Review 09:30-10:30Session 1: Adapting incident detection and response in the maritime domain 10:30-10:45Break 10:45-11:45Session 2: Tabletop exercise focusing on risk assessment to systems and applying mitigating factors 11:45-13:00Lunch 13:00-14:15Session 3: Complete TTX & wrap-up talk: coordination with IMEC 14:15-14:45Session 4: Next Steps: Adopting maritime cybersecurity controls 14:45-15:00Closing Remarks and Adjourn

| ID | WBS | Task | Type | Duration | Start | Finish | Predecessors | Total slack | Free slack | Constraint | Text7 |
| --- | --- | --- | --- | --- | --- | --- | --- | --- | --- | --- | --- |
| 56 | 6.2 | **Workshop Two** |  | 17d | 2022-06-13 | 2022-07-05 |  | 64d |  |  |  |
| 57 | 6.2.1 | Day 1 |  | 1d | 2022-06-13 | 2022-06-13 |  | 64d | 0d | start no earlier than 2022-06-13 |  |
| 58 | 6.2.2 | Day 2 |  | 1d | 2022-06-14 | 2022-06-14 | 57 | 64d | 0d | start no earlier than 2022-05-10 |  |
| 59 | 6.2.3 | Day 3 |  | 1d | 2022-06-15 | 2022-06-15 | 58 | 64d | 0d | start no earlier than 2022-03-09 |  |
| 60 | 6.2.4 | Event Report |  | 14d | 2022-06-16 | 2022-07-05 | 59 | 64d | 0d |  |  |
| 61 | 6.2.5 | Workshop complete and Event Report Submited | milestone | 0d | 2022-07-05 | 2022-07-05 | 60 | 64d |  |  |  |
| 62 | 7 | **Closing** |  | 6d? | 2021-10-26 | 2021-11-02 |  |  |  |  |  |
| 63 | 7.1 | Close Project |  | 1d | 2022-09-30 | 2022-09-30 |  | 0d |  | start no earlier than 2022-09-30 |  |
| 64 | 7.2 | **Contract Closure** |  | 1d | 2022-10-03 | 2022-10-03 |  | 0d |  |  |  |
| 65 | 7.2.1 | Close Contract |  | 1d | 2022-10-03 | 2022-10-03 | 63 | 0d |  |  | Contract Files, Subcontractor Payments |

Notes:
- 57: 09:00-09:30Welcome and Introduction 09:30-10:30Session 1: Discussion on APT threat landscape and intersection of cyber domain and marine global transportation industry 10:30-10:45Break 10:45-11:45Session 2: Case study emphasizing severity, impact, and cybersecurity gaps facing the maritime industry 11:45-13:00Lunch 13:00-14:00Session 3: Foundational cybersecurity best practices and background development to ensure understanding at all levels 14:00-14:15Break 14:15-15:30Session 4: Utilizing cybersecurity controls and frameworks in the maritime industry 15:30-16:00End-of-Day Remarks and Adjourn
- 58: 09:00-09:30Welcome and Day 1 Review 09:30-10:30Session 1: Vessel and port-specific cybersecurity risk and mitigation strategies 10:30-10:45Break 10:45-11:45Session 2: Breakdown of IMO, BIMCO, and other international standards 11:45-13:00Lunch 13:00-14:00Session 3: National and regional cybersecurity and maritime security requirements and how they can protect against cyber aggression 14:00-14:15Break 14:15-15:30Session 4: Overview of maritime cyber assessment for partners, how to conduct, apply mitigations, and reassess for continual improvement 15:30-16:00End-of-Day Remarks and Adjourn
- 59: 09:00-09:30Welcome and Day 2 Review 09:30-10:30Session 1: Adapting incident detection and response in the maritime domain 10:30-10:45Break 10:45-11:45Session 2: Tabletop exercise focusing on risk assessment to systems and applying mitigating factors 11:45-13:00Lunch 13:00-14:15Session 3: Complete TTX & wrap-up talk: coordination with IMEC 14:15-14:45Session 4: Next Steps: Adopting maritime cybersecurity controls 14:45-15:00Closing Remarks and Adjourn
- 62: Text1: VPEND<VP ID="0_129436" TYP="0" />
- 63: Make sure that the project is properly closed down, either when project delivery is complete or when the project is terminated for whatever reason. / Text1: VPEND<VP ID="0_81855" TYP="0"><VP ID="0_107335" TYP="3" /></VP>
- 64: Blab / Text1: VPEND<VP ID="0_168529" TYP="0" />
- 65: Specific actions required to ensure acceptance of deliverables, process final payments and archive and close out project contract files. / Text1: VPEND<VP ID="0_168537" TYP="0"><VP ID="0_17261" TYP="2" /><VP ID="0_92687" TYP="2" /><VP ID="0_17305" TYP="1" /></VP>
